# План выполнения работ, ред. 01

Schedule from MS Project, 2011-03-14 to 2011-06-24, costs in р..
***

## Calendars

- Стандартный: Mon-Fri 09:00-13:00, 14:00-18:00; Sat-Sun off.

## Resources

| Resource | Rate |
| --- | --- |
| Руководитель проекта | 400 |
| Разработчик системы 1 | 350 |
| Разработчик системы 2 | 350 |
| Архитектор системы | 350 |
| Постановщик задач исполнителя 1 | 300 |
| Технический специалист | 300 |
| Специалист по внедрению | 300 |
| Разработчик документации | 250 |

## Schedule

| ID | WBS | Task | Duration | Start | Finish | Predecessors | Total slack | Free slack | Constraint | Resources | Work | Cost |
| --- | --- | --- | --- | --- | --- | --- | --- | --- | --- | --- | --- | --- |
| 1 | 1 | **Создание информационной системы «БАЛТИК-ЛАЙТ»** | 75d | 2011-03-14 | 2011-06-24 |  | 0d |  |  |  | 1380h | 466,600 |
| 2 | 1.1 | **Этап 1. Разработка технического задания информационной системы** | 16d | 2011-03-14 | 2011-04-04 |  | 0d |  |  |  | 128h | 38,400 |
| 3 | 1.1.1 | Состав и набор реквизитов информационных объектов учета и анализа | 10d | 2011-03-14 | 2011-03-25 |  | 0d |  | start no earlier than 2011-03-14 | Постановщик задач исполнителя 1 | 80h | 24,000 |
| 4 | 1.1.2 | Состав и дизайн бланк - форм для печати документов. Согласование | 3d | 2011-03-28 | 2011-03-30 | 3 | 0d |  |  | Постановщик задач исполнителя 1 | 24h | 7,200 |
| 5 | 1.1.3 | Состав и дизайн аналитических отчетов | 2d | 2011-03-31 | 2011-04-01 | 4 | 0d |  |  | Постановщик задач исполнителя 1 | 16h | 4,800 |
| 6 | 1.1.4 | План-график выполнения работ | 1d | 2011-04-04 | 2011-04-04 | 5 | 0d |  | start no earlier than 2010-05-10 | Постановщик задач исполнителя 1 | 8h | 2,400 |
| 7 | 1.2 | **Этап 2. Прием заявок и обеспечение производства** | 47d | 2011-04-05 | 2011-06-08 |  | 0d |  |  |  | 544h | 184,800 |
| 8 | 1.2.1 | Настройка информационных объектов учета и анализа для разрабатываемых подсистем Прием заявок и обеспечение производства | 5d | 2011-04-05 | 2011-04-11 | 6 | 54d |  |  | Архитектор системы | 40h | 14,000 |
| 9 | 1.2.2 | Установка и настройка БД БАЛТИК-ЛАЙТ | 1d | 2011-04-05 | 2011-04-05 | 6 | 0d |  |  | Технический специалист | 8h | 2,400 |
| 10 | 1.2.3 | Миграция данных из существующих систем (1С, Excel) | 8d | 2011-04-06 | 2011-04-15 | 9 | 50d |  | start no earlier than 2010-05-10 | Технический специалист | 64h | 19,200 |
| 11 | 1.2.4 | Настройка оргштатной структуры компании | 1d | 2011-04-06 | 2011-04-06 | 9 | 57d |  |  | Архитектор системы | 8h | 2,800 |
| 12 | 1.2.5 | Классификация сырья и материалов | 3d | 2011-04-06 | 2011-04-08 | 9 | 0d |  |  | Архитектор системы | 24h | 8,400 |
| 13 | 1.2.6 | Типизация продукции | 4d | 2011-04-11 | 2011-04-14 | 12 | 0d |  |  | Разработчик системы 1 | 32h | 11,200 |
| 14 | 1.2.7 | Разработка требуемой функциональности и уровней доступа к системе | 20d | 2011-04-06 | 2011-05-03 | 9 | 12d | 0d |  | Разработчик системы 1 | 160h | 56,000 |
| 15 | 1.2.8 | Формирование необходимых печатных форм в рамках процессов Прием заявок и обеспечение производства | 21d | 2011-05-04 | 2011-06-01 | 14 | 12d | 0d |  | Разработчик системы 2 | 168h | 58,800 |
| 16 | 1.2.9 | Отладка разработанных подсистем и исправление ошибок | 4d | 2011-06-02 | 2011-06-07 | 15 | 12d | 0d |  | Специалист по внедрению | 32h | 9,600 |
| 17 | 1.2.10 | Обучение и тестовая эксплуатация | 1d | 2011-06-08 | 2011-06-08 | 16 | 12d |  |  | Специалист по внедрению | 8h | 2,400 |
| 18 | 1.3 | **Этап 3. Производство, транспортировка, монтаж** | 32.5d | 2011-04-15 | 2011-05-31 |  | 0d |  |  |  | 372h | 128,600 |
| 19 | 1.3.1 | Настройка информационных объектов учета и анализа для разрабатываемых подсистем Производство, транспортировка, монтаж | 10d | 2011-04-15 | 2011-04-28 | 13 | 0d |  | start no earlier than 2010-05-10 | Архитектор системы | 80h | 28,000 |
| 20 | 1.3.2 | Разработка требуемой функциональности для подсистемы Производство, транспортировка, монтаж | 22.5d | 2011-04-29 | 2011-05-31 | 19 | 18.5d |  |  | Разработчик системы 1 | 180h | 63,000 |
| 21 | 1.3.3 | Формирование необходимых печатных форм в рамках процессов Производство, транспортировка, монтаж | 10d | 2011-04-29 | 2011-05-12 | 19 | 0d |  |  | Разработчик системы 2 | 80h | 28,000 |
| 22 | 1.3.4 | Отладка разработанных подсистем и исправление ошибок | 3d | 2011-05-13 | 2011-05-17 | 21 | 0d |  |  | Специалист по внедрению | 24h | 7,200 |
| 23 | 1.3.5 | Обучение и тестовая эксплуатация | 1d | 2011-05-18 | 2011-05-18 | 22 | 0d |  |  | Специалист по внедрению | 8h | 2,400 |
| 24 | 1.4 | **Этап 4. Финансы и кадры** | 24d | 2011-05-19 | 2011-06-21 |  | 0d |  |  |  | 312h | 107,600 |
| 25 | 1.4.1 | Настройка информационных объектов учета и анализа для разрабатываемых подсистем Финансы и кадры | 8d | 2011-05-19 | 2011-05-30 | 23 | 0d |  | start no earlier than 2010-05-10 | Архитектор системы | 64h | 22,400 |
| 26 | 1.4.2 | Разработка требуемой функциональности для подсистемы Финансы и кадры | 15d | 2011-05-31 | 2011-06-20 | 25 | 4d |  |  | Разработчик системы 1 | 120h | 42,000 |
| 27 | 1.4.3 | Формирование необходимых печатных форм в рамках процессов Финансы и кадры | 12d | 2011-05-31 | 2011-06-15 | 25 | 0d |  |  | Разработчик системы 2 | 96h | 33,600 |
| 28 | 1.4.4 | Отладка разработанных подсистем и исправление ошибок | 2d | 2011-06-16 | 2011-06-17 | 27 | 0d |  |  | Специалист по внедрению | 16h | 4,800 |
| 29 | 1.4.5 | Обучение и тестовая эксплуатация | 2d | 2011-06-20 | 2011-06-21 | 28 | 0d |  |  | Специалист по внедрению | 16h | 4,800 |
| 30 | 1.5 | Тестовая эксплуатация системы в целом и запуск в промышленную эксплуатацию | 3d | 2011-06-22 | 2011-06-24 | 29 | 0d |  |  | Специалист по внедрению | 24h | 7,200 |
